# Внедрение Exchange (СДР и ресурсы)

How a schedule from MS Project changed from version to version. A marks actual dates.

## Version 1 (data date 2010-07-12, saved 2012-04-28, file n9w8f3_Vnedrenie-Exchange-SDR-i-resursyi.mpp)

| ID | WBS | Task | Duration | Start | Finish | Total float | Constraint |
| --- | --- | --- | --- | --- | --- | --- | --- |
| 1 |  | Начало проекта | 0d | 2010-04-26 | 2010-04-26 | 57d |  |
| 2 |  | Проект завершен | 0d | 2010-04-26 | 2010-04-26 | 57d |  |
| 3 | 3 | **Обученные пользователи** | 57d | 2010-04-26 | 2010-07-13 | 0d |  |
| 4 | 3.1 | **Подготовить тренеров** | 10d | 2010-04-26 | 2010-05-07 | 0d |  |
| 5 |  | Согласовать программу обучения тренеров с Заказчиком | 2d | 2010-04-26 | 2010-04-27 | 55d |  |
| 6 |  | Подписать договор на обучение тренеров | 2d | 2010-04-26 | 2010-04-27 | 0d |  |
| 7 |  | Пройти обучение для тренеров | 10d | 2010-04-26 | 2010-05-07 | 47d |  |
| 8 |  | Тренеры прошли обучение по работе с Системой | 0d | 2010-04-26 | 2010-04-26 | 57d |  |
| 9 | 3.2 | **Обучить топ-менеджеров** | 10d | 2010-04-26 | 2010-05-07 | 47d |  |
| 10 |  | Согласовать программу обучения топ-менеджеров с Заказчиком | 5d | 2010-04-26 | 2010-04-30 | 52d |  |
| 11 |  | Подготовить раздаточные материалы для обучения топ-менеджеров | 10d | 2010-04-26 | 2010-05-07 | 47d |  |
| 12 |  | Согласовать график проведения обучения с топ-менеджерами | 5d | 2010-04-26 | 2010-04-30 | 52d |  |
| 13 |  | Провести обучение топ-менеджеров (группа 1) | 3d | 2010-04-26 | 2010-04-28 | 54d |  |
| 14 |  | Провести обучение топ-менеджеров (группа 2) | 5d | 2010-04-26 | 2010-04-30 | 52d |  |
| 15 |  | Провести обучение топ-менеджеров (группа 3) | 1d | 2010-04-26 | 2010-04-26 | 56d |  |
| 16 |  | Топ-менеджеры прошли обучение | 0d | 2010-04-26 | 2010-04-26 | 57d |  |
| 17 | 3.3 | **Обучить специалистов ИТ** | 10d | 2010-04-26 | 2010-05-07 | 47d |  |
| 18 |  | Согласовать программу обучения ИТ специалистов с Заказчиком | 2d | 2010-04-26 | 2010-04-27 | 55d |  |
| 19 |  | Подписать договор на обучение ИТ специалистов | 2d | 2010-04-26 | 2010-04-27 | 55d |  |
| 20 |  | Пройти обучение для ИТ-специалистов | 10d | 2010-04-26 | 2010-05-07 | 47d |  |
| 21 |  | ИТ-специалисты прошли обучение | 0d | 2010-04-26 | 2010-04-26 | 57d |  |
| 22 | 3.4 | **Обучить менеджеров среднего звена** | 57d | 2010-04-26 | 2010-07-13 | 0d |  |
| 23 |  | Согласовать список менеджеров среднего звена к обучению с разбиением на группы | 4d | 2010-04-26 | 2010-04-29 | 53d |  |
| 24 |  | Согласовать график проведения обучения с менджерами среднего звена | 4d | 2010-04-26 | 2010-04-29 | 53d |  |
| 25 |  | Провести обучение менеджеров среднего звена (группа 1) | 2d | 2010-07-12 | 2010-07-13 | 0d | start no earlier than 2010-07-12 |
| 26 |  | Провести обучение менеджеров среднего звена (группа 2) | 4d | 2010-04-26 | 2010-04-29 | 53d |  |
| 27 |  | Провести обучение менеджеров среднего звена (группа 3) | 4d | 2010-04-26 | 2010-04-29 | 53d |  |
| 28 |  | Провести обучение менеджеров среднего звена (группа 4) | 3d | 2010-04-26 | 2010-04-28 | 54d |  |
| 29 |  | Провести обучение менеджеров среднего звена (группа 5) | 2d | 2010-04-26 | 2010-04-27 | 55d |  |
| 30 |  | Оценить результаты обучения менеджеров среднего звена | 5d | 2010-04-26 | 2010-04-30 | 52d |  |
| 31 |  | Менеджеры среднего звена прошли обучение | 0d | 2010-04-26 | 2010-04-26 | 57d |  |
| 32 | 4 | **Настроенная Система** | 10d | 2010-04-26 | 2010-05-07 | 0d |  |
| 33 | 4.1 | **Подготовить требования к Системе** | 3d | 2010-04-26 | 2010-04-28 | 0d |  |
| 34 |  | Подготовить требования к настройке Системы. Направить на согласование | 2d | 2010-04-26 | 2010-04-27 | 55d |  |
| 35 |  | Согласовать требования к настройке Системы. Высказать замечания | 3d | 2010-04-26 | 2010-04-28 | 54d |  |
| 36 |  | Доработать требования к настройке Системы согласно замечаниям | 1d | 2010-04-26 | 2010-04-26 | 56d |  |
| 37 |  | Подписать требования к настройке Системы | 0d | 2010-04-26 | 2010-04-26 | 0d |  |
| 38 | 4.2 | **Настроить серверную часть** | 10d | 2010-04-26 | 2010-05-07 | 47d |  |
| 39 |  | Настроить серверную часть Календарь | 4d | 2010-04-26 | 2010-04-29 | 53d |  |
| 40 |  | Настроить серверную часть Почта | 4d | 2010-04-26 | 2010-04-29 | 53d |  |
| 41 |  | Настроить серверную часть Задачи | 4d | 2010-04-26 | 2010-04-29 | 53d |  |
| 42 |  | Настроить серверную часть Контакты | 4d | 2010-04-26 | 2010-04-29 | 53d |  |
| 43 |  | Настроить серверную часть Синхронизация и удаленный доступ | 10d | 2010-04-26 | 2010-05-07 | 47d |  |
| 44 |  | Настроить серверную часть Технические настройки | 4d | 2010-04-26 | 2010-04-29 | 53d |  |
| 45 |  | Проверить работоспособность настроенных функций | 2d | 2010-04-26 | 2010-04-27 | 55d |  |
| 46 |  | Серверная часть настроена в соответствии с требованиями | 0d | 2010-04-26 | 2010-04-26 | 57d |  |
| 47 | 5 | **Документация к Системе** | 57d | 2010-04-26 | 2010-07-13 | 0d |  |
| 48 |  | Описать настройки Системы (адреса, пароли и явки) | 5d | 2010-04-26 | 2010-04-30 | 52d |  |
| 49 |  | Предоставить формат описания пользовательской документации | 5d | 2010-07-07 | 2010-07-13 | 0d | as late as possible |
| 50 |  | Разработать документацию к Системе. Календарь | 5d | 2010-04-26 | 2010-04-30 | 52d |  |
| 51 |  | Разработать документацию к Системе. Почта | 5d | 2010-04-26 | 2010-04-30 | 52d |  |
| 52 |  | Разработать документацию к Системе. Задачи | 5d | 2010-04-26 | 2010-04-30 | 52d |  |
| 53 |  | Разработать документацию к Системе. Контакты | 5d | 2010-04-26 | 2010-04-30 | 52d |  |
| 54 |  | Разработать документацию к Системе. Синхронизация и удаленный доступ | 5d | 2010-04-26 | 2010-04-30 | 52d |  |
| 55 |  | Разработать документацию к Системе. Администрирование и поддержка Системы | 5d | 2010-04-26 | 2010-04-30 | 52d |  |
| 56 |  | Подписать Акт сдачи-приемки документации к Системе | 2d | 2010-04-26 | 2010-04-27 | 55d |  |
| 57 |  | Резерв времени на разработку документации к Системе | 20d | 2010-04-26 | 2010-05-21 | 37d |  |
| 58 |  | Утвердить документацию к Системе на СД | 5d | 2010-04-26 | 2010-04-30 | 52d |  |
| 59 |  | Ознакомить пользователей с документацией к Системе | 5d | 2010-04-26 | 2010-04-30 | 52d |  |
| 60 |  | Заказчик принял документацию. Пользователи ознакомлены с документацией | 0d | 2010-04-26 | 2010-04-26 | 57d |  |
| 61 | 6 | **Миграция пользователей и настройка клиентских мест** | 57d | 2010-04-26 | 2010-07-13 | 0d |  |
| 62 |  | Подготовить check-list выполнения миграции пользователей | 5d | 2010-04-26 | 2010-04-30 | 52d |  |
| 63 |  | Проверить check-list. Высказать замечания | 2d | 2010-04-26 | 2010-04-27 | 55d |  |
| 64 |  | Доработать check-list в соответствии с замечаниями | 2d | 2010-04-26 | 2010-04-27 | 55d |  |
| 65 |  | Провести миграцию тестовой группы пользователей | 5d | 2010-04-26 | 2010-04-30 | 52d |  |
| 66 |  | Оценить результаты. Доработать check-list | 2d | 2010-04-26 | 2010-04-27 | 55d |  |
| 67 |  | Разработать список пользователей к миграции с детализацией до компании | 5d | 2010-07-07 | 2010-07-13 | 0d | as late as possible |
| 68 |  | Согласовать график проведения миграции с пользователями | 5d | 2010-04-26 | 2010-04-30 | 52d |  |
| 69 |  | Обеспечить миграцию топ-менеджеров, УК | 5d | 2010-04-26 | 2010-04-30 | 52d |  |
| 70 |  | Подписать акт сдачи-приемки миграции топ-менеджеров и сотрудников УК | 0d | 2010-04-26 | 2010-04-26 | 57d |  |

| ID | WBS | Task | Duration | Start | Finish | Total float |
| --- | --- | --- | --- | --- | --- | --- |
| 71 |  | Обеспечить миграцию пользователей компании А | 5d | 2010-04-26 | 2010-04-30 | 52d |
| 72 |  | Подписать акт сдачи-приемки миграции А | 0d | 2010-04-26 | 2010-04-26 | 57d |
| 73 |  | Обеспечить миграцию пользователей компании Б | 5d | 2010-04-26 | 2010-04-30 | 52d |
| 74 |  | Подписать акт сдачи-приемки миграции Б | 0d | 2010-04-26 | 2010-04-26 | 57d |
| 75 |  | Обеспечить миграцию пользователей компании В | 5d | 2010-04-26 | 2010-04-30 | 52d |
| 76 |  | Подписать акт сдачи-приемки миграции В | 0d | 2010-04-26 | 2010-04-26 | 57d |
| 77 |  | Обеспечить миграцию пользователей компании Г | 5d | 2010-04-26 | 2010-04-30 | 52d |
| 78 |  | Подписать акт сдачи-приемки миграции Г | 0d | 2010-04-26 | 2010-04-26 | 57d |
| 79 |  | Обеспечить миграцию пользователей филиалов | 10d | 2010-04-26 | 2010-05-07 | 47d |
| 80 |  | Подписать акт сдачи-приемки миграции филиалов | 0d | 2010-04-26 | 2010-04-26 | 57d |
| 81 |  | Миграция пользователей и настройка клиентских мест завершена | 0d | 2010-04-26 | 2010-04-26 | 57d |
| 82 | 7 | **Оборудование** | 5d | 2010-04-26 | 2010-04-30 | 52d |
| 83 |  | Подать заявку на приобретение оборудования | 5d | 2010-04-26 | 2010-04-30 | 52d |
| 84 |  | Закупить оборудование в соответствии с Заявкой | 1d | 2010-04-26 | 2010-04-26 | 56d |
| 85 |  | Установить оборудование | 3d | 2010-04-26 | 2010-04-28 | 54d |
| 86 |  | Настроить и проверить работоспособность оборудование | 5d | 2010-04-26 | 2010-04-30 | 52d |
| 87 |  | Оборудование приобретено, настроено и проверено | 0d | 2010-04-26 | 2010-04-26 | 57d |

## Version 2 (data date 2010-07-12, saved 2012-09-07, file 3fli0f_Vnedrenie-Exchange-polnaya-versiya.mpp)

Last finish 2010-07-13 → 2010-11-05 (+115d). Complete tasks 0 → 14.

Changed:

| ID | Task | Start | Finish | Duration | Complete | Total float | Predecessors | Other |
| --- | --- | --- | --- | --- | --- | --- | --- | --- |
| 1 | Начало проекта | 2010-04-26 → 2010-05-10 A (+14d) | 2010-04-26 → 2010-05-10 A (+14d) |  | 0% → 100% | 57d → none |  | constraint none → start no earlier than 2010-05-10; baseline start none → 2010-05-10; baseline finish none → 2010-05-10 |
| 2 | Проект завершен | 2010-04-26 → 2010-11-05 (+193d) | 2010-04-26 → 2010-11-05 (+193d) |  |  | 57d → 0d | none → 60, 81, 8, 16, 21, 46, 87, 31 | baseline start none → 2010-10-04; baseline finish none → 2010-10-04 |
| 3 | **Обученные пользователи** | 2010-04-26 → 2010-05-10 A (+14d) | 2010-07-13 → 2010-08-17 (+35d) | 57d → 72d | 0% → 51% | 0d → 58d |  | baseline start none → 2010-05-10; baseline finish none → 2010-08-24 |
| 4 | **Подготовить тренеров** | 2010-04-26 → 2010-05-10 A (+14d) | 2010-05-07 → 2010-05-25 A (+18d) | 10d → 12d | 0% → 100% | 0d → none |  | baseline start none → 2010-05-10; baseline finish none → 2010-05-25 |
| 5 | Согласовать программу обучения тренеров с Заказчиком | 2010-04-26 → 2010-05-10 A (+14d) | 2010-04-27 → 2010-05-11 A (+14d) |  | 0% → 100% | 55d → none | none → 1 | baseline start none → 2010-05-10; baseline finish none → 2010-05-11 |
| 6 | Подписать договор на обучение тренеров | 2010-04-26 → 2010-05-10 A (+14d) | 2010-04-27 → 2010-05-11 A (+14d) |  | 0% → 100% | 0d → none | none → 1 | baseline start none → 2010-05-10; baseline finish none → 2010-05-11 |
| 7 | Пройти обучение для тренеров | 2010-04-26 → 2010-05-12 A (+16d) | 2010-05-07 → 2010-05-25 A (+18d) |  | 0% → 100% | 47d → none | none → 5, 6 | baseline start none → 2010-05-12; baseline finish none → 2010-05-25 |
| 8 | Тренеры прошли обучение по работе с Системой | 2010-04-26 → 2010-05-25 A (+29d) | 2010-04-26 → 2010-05-25 A (+29d) |  | 0% → 100% | 57d → none | none → 7 | baseline start none → 2010-05-25; baseline finish none → 2010-05-25 |
| 9 | **Обучить топ-менеджеров** | 2010-04-26 → 2010-05-19 A (+23d) | 2010-05-07 → 2010-07-08 A (+62d) | 10d → 37d | 0% → 100% | 47d → none |  | baseline start none → 2010-05-19; baseline finish none → 2010-06-29 |
| 10 | Согласовать программу обучения топ-менеджеров с Заказчиком | 2010-04-26 → 2010-05-19 A (+23d) | 2010-04-30 → 2010-05-25 A (+25d) |  | 0% → 100% | 52d → none | none → 1 | constraint none → as late as possible; baseline start none → 2010-05-19; baseline finish none → 2010-05-25 |
| 11 | Подготовить раздаточные материалы для обучения топ-менеджеров | 2010-04-26 → 2010-05-26 A (+30d) | 2010-05-07 → 2010-06-08 A (+32d) |  | 0% → 100% | 47d → none | none → 10, 8 | baseline start none → 2010-05-26; baseline finish none → 2010-06-08 |
| 12 | Согласовать график проведения обучения с топ-менеджерами | 2010-04-26 → 2010-05-26 A (+30d) | 2010-04-30 → 2010-06-01 A (+32d) |  | 0% → 100% | 52d → none | none → 8 | baseline start none → 2010-05-26; baseline finish none → 2010-06-01 |
| 13 | Провести обучение топ-менеджеров (группа 1) | 2010-04-26 → 2010-06-09 A (+44d) | 2010-04-28 → 2010-06-11 A (+44d) |  | 0% → 100% | 54d → none | none → 12, 11 | baseline start none → 2010-06-09; baseline finish none → 2010-06-15 |
| 14 | Провести обучение топ-менеджеров (группа 2) | 2010-04-26 → 2010-06-14 A (+49d) | 2010-04-30 → 2010-06-18 A (+49d) |  | 0% → 100% | 52d → none | none → 13 | baseline start none → 2010-06-16; baseline finish none → 2010-06-22 |
| 15 | Провести обучение топ-менеджеров (группа 3) | 2010-04-26 → 2010-07-08 A (+73d) | 2010-04-26 → 2010-07-08 A (+73d) |  | 0% → 100% | 56d → none | none → 14 | baseline start none → 2010-06-23; baseline finish none → 2010-06-29 |
| 16 | Топ-менеджеры прошли обучение | 2010-04-26 → 2010-07-08 A (+73d) | 2010-04-26 → 2010-07-08 A (+73d) |  | 0% → 100% | 57d → none | none → 15 | baseline start none → 2010-06-29; baseline finish none → 2010-06-29 |
| 17 | **Обучить специалистов ИТ** | 2010-04-26 → 2010-08-02 (+98d) | 2010-05-07 → 2010-08-17 (+102d) | 10d → 12d |  | 47d → 58d |  | baseline start none → 2010-06-03; baseline finish none → 2010-06-18 |
| 18 | Согласовать программу обучения ИТ специалистов с Заказчиком | 2010-04-26 → 2010-08-02 (+98d) | 2010-04-27 → 2010-08-03 (+98d) |  |  | 55d → 58d | none → 1 | constraint none → start no earlier than 2010-08-02; baseline start none → 2010-06-03; baseline finish none → 2010-06-04 |
| 19 | Подписать договор на обучение ИТ специалистов | 2010-04-26 → 2010-08-02 (+98d) | 2010-04-27 → 2010-08-03 (+98d) |  |  | 55d → 58d | none → 1 | constraint none → start no earlier than 2010-08-02 |
| 20 | Пройти обучение для ИТ-специалистов | 2010-04-26 → 2010-08-04 (+100d) | 2010-05-07 → 2010-08-17 (+102d) |  |  | 47d → 58d | none → 19, 18 | baseline start none → 2010-06-07; baseline finish none → 2010-06-18 |
| 21 | ИТ-специалисты прошли обучение | 2010-04-26 → 2010-08-17 (+113d) | 2010-04-26 → 2010-08-17 (+113d) |  |  | 57d → 58d | none → 20 | baseline start none → 2010-06-18; baseline finish none → 2010-06-18 |
| 22 | **Обучить менеджеров среднего звена** | 2010-04-26 → 2010-07-09 (+74d) | 2010-07-13 → 2010-08-11 (+29d) | 57d → 24d |  | 0d → 62d |  | baseline start none → 2010-06-30; baseline finish none → 2010-08-24 |
| 23 | Согласовать список менеджеров среднего звена к обучению с разбиением на группы | 2010-04-26 → 2010-07-09 (+74d) | 2010-04-29 → 2010-07-14 (+76d) |  |  | 53d → 62d | none → 16 | baseline start none → 2010-06-30; baseline finish none → 2010-07-06 |
| 24 | Согласовать график проведения обучения с менджерами среднего звена | 2010-04-26 → 2010-07-09 (+74d) | 2010-04-29 → 2010-07-14 (+76d) |  |  | 53d → 62d | none → 16 | baseline start none → 2010-06-30; baseline finish none → 2010-07-06 |
| 25 | Провести обучение менеджеров среднего звена (группа 1) | 2010-07-12 → 2010-07-15 (+3d) | 2010-07-13 → 2010-07-16 (+3d) |  |  | 0d → 62d | none → 24, 23 | baseline start none → 2010-07-07; baseline finish none → 2010-07-13 |
| 26 | Провести обучение менеджеров среднего звена (группа 2) | 2010-04-26 → 2010-07-19 (+84d) | 2010-04-29 → 2010-07-22 (+84d) |  |  | 53d → 62d | none → 25 | baseline start none → 2010-07-14; baseline finish none → 2010-07-20 |
| 27 | Провести обучение менеджеров среднего звена (группа 3) | 2010-04-26 → 2010-07-23 (+88d) | 2010-04-29 → 2010-07-28 (+90d) |  |  | 53d → 62d | none → 26 | baseline start none → 2010-07-21; baseline finish none → 2010-07-27 |
| 28 | Провести обучение менеджеров среднего звена (группа 4) | 2010-04-26 → 2010-07-29 (+94d) | 2010-04-28 → 2010-08-02 (+96d) |  |  | 54d → 62d | none → 27 | baseline start none → 2010-07-28; baseline finish none → 2010-08-03 |
| 29 | Провести обучение менеджеров среднего звена (группа 5) | 2010-04-26 → 2010-08-03 (+99d) | 2010-04-27 → 2010-08-04 (+99d) |  |  | 55d → 62d | none → 28 | baseline start none → 2010-08-04; baseline finish none → 2010-08-10 |
| 30 | Оценить результаты обучения менеджеров среднего звена | 2010-04-26 → 2010-08-05 (+101d) | 2010-04-30 → 2010-08-11 (+103d) |  |  | 52d → 62d | none → 29 | baseline start none → 2010-08-11; baseline finish none → 2010-08-24 |
| 31 | Менеджеры среднего звена прошли обучение | 2010-04-26 → 2010-08-11 (+107d) | 2010-04-26 → 2010-08-11 (+107d) |  |  | 57d → 62d | none → 30 | baseline start none → 2010-08-24; baseline finish none → 2010-08-24 |
| 32 | **Настроенная Система** | 2010-04-26 → 2010-07-09 (+74d) | 2010-05-07 → 2010-09-08 (+124d) | 10d → 44d |  |  |  | baseline start none → 2010-06-16; baseline finish none → 2010-08-05 |
| 33 | **Подготовить требования к Системе** | 2010-04-26 → 2010-07-09 (+74d) | 2010-04-28 → 2010-08-17 (+111d) | 3d → 28d |  |  |  | baseline start none → 2010-06-16; baseline finish none → 2010-07-14 |
| 34 | Подготовить требования к настройке Системы. Направить на согласование | 2010-04-26 → 2010-07-09 (+74d) | 2010-04-27 → 2010-08-11 (+106d) | 2d → 24d |  | 55d → 0d | none → 16 | baseline start none → 2010-06-30; baseline finish none → 2010-07-06 |
| 35 | Согласовать требования к настройке Системы. Высказать замечания | 2010-04-26 → 2010-08-12 (+108d) | 2010-04-28 → 2010-08-16 (+110d) |  |  | 54d → 0d | none → 34 | baseline start none → 2010-07-07; baseline finish none → 2010-07-08 |
| 36 | Доработать требования к настройке Системы согласно замечаниям | 2010-04-26 → 2010-08-17 (+113d) | 2010-04-26 → 2010-08-17 (+113d) |  |  | 56d → 0d | none → 35 | baseline start none → 2010-07-09; baseline finish none → 2010-07-13 |
| 37 | Подписать требования к настройке Системы | 2010-04-26 → 2010-08-17 (+113d) | 2010-04-26 → 2010-08-17 (+113d) |  |  |  | none → 36 | baseline start none → 2010-07-14; baseline finish none → 2010-07-14 |
| 38 | **Настроить серверную часть** | 2010-04-26 → 2010-08-18 (+114d) | 2010-05-07 → 2010-09-08 (+124d) | 10d → 16d |  | 47d → 0d |  | baseline start none → 2010-07-15; baseline finish none → 2010-08-05 |
| 39 | Настроить серверную часть Календарь | 2010-04-26 → 2010-08-18 (+114d) | 2010-04-29 → 2010-08-23 (+116d) |  |  | 53d → 0d | none → 37 | baseline start none → 2010-07-15; baseline finish none → 2010-07-20 |
| 40 | Настроить серверную часть Почта | 2010-04-26 → 2010-08-24 (+120d) | 2010-04-29 → 2010-08-27 (+120d) |  |  | 53d → 0d | none → 39 | baseline start none → 2010-07-21; baseline finish none → 2010-07-26 |
| 41 | Настроить серверную часть Задачи | 2010-04-26 → 2010-08-30 (+126d) | 2010-04-29 → 2010-09-02 (+126d) |  |  | 53d → 0d | none → 40 | baseline start none → 2010-07-27; baseline finish none → 2010-07-30 |
| 42 | Настроить серверную часть Контакты | 2010-04-26 → 2010-09-03 (+130d) | 2010-04-29 → 2010-09-08 (+132d) |  |  | 53d → 0d | none → 41 | baseline start none → 2010-08-02; baseline finish none → 2010-08-05 |
| 43 | Настроить серверную часть Синхронизация и удаленный доступ | 2010-04-26 → 2010-08-18 (+114d) | 2010-05-07 → 2010-08-31 (+116d) |  |  | 47d → 0d | none → 37 | baseline start none → 2010-07-15; baseline finish none → 2010-07-28 |
| 44 | Настроить серверную часть Технические настройки | 2010-04-26 → 2010-09-01 (+128d) | 2010-04-29 → 2010-09-06 (+130d) |  |  | 53d → 0d | none → 43 | baseline start none → 2010-07-29; baseline finish none → 2010-08-03 |
| 45 | Проверить работоспособность настроенных функций | 2010-04-26 → 2010-09-07 (+134d) | 2010-04-27 → 2010-09-08 (+134d) |  |  | 55d → 0d | none → 44 | baseline start none → 2010-08-04; baseline finish none → 2010-08-05 |
| 46 | Серверная часть настроена в соответствии с требованиями | 2010-04-26 → 2010-09-08 (+135d) | 2010-04-26 → 2010-09-08 (+135d) |  |  | 57d → 0d | none → 45, 42 | baseline start none → 2010-08-05; baseline finish none → 2010-08-05 |
| 47 | **Документация к Системе** | 2010-04-26 → 2010-08-19 (+115d) | 2010-07-13 → 2010-11-05 (+115d) |  |  |  |  | baseline start none → 2010-07-16; baseline finish none → 2010-10-04 |
| 48 | Описать настройки Системы (адреса, пароли и явки) | 2010-04-26 → 2010-09-09 (+136d) | 2010-04-30 → 2010-09-15 (+138d) |  |  | 52d → 0d | none → 46 | baseline start none → 2010-08-06; baseline finish none → 2010-08-12 |
| 49 | Предоставить формат описания пользовательской документации | 2010-07-07 → 2010-08-19 (+43d) | 2010-07-13 → 2010-08-25 (+43d) |  |  |  | none → 1 | baseline start none → 2010-07-16; baseline finish none → 2010-07-22 |
| 50 | Разработать документацию к Системе. Календарь | 2010-04-26 → 2010-08-26 (+122d) | 2010-04-30 → 2010-09-01 (+124d) |  |  | 52d → 0d | none → 39, 49 | baseline start none → 2010-07-23; baseline finish none → 2010-07-29 |
| 51 | Разработать документацию к Системе. Почта | 2010-04-26 → 2010-09-02 (+129d) | 2010-04-30 → 2010-09-08 (+131d) |  |  | 52d → 0d | none → 50, 40 | baseline start none → 2010-07-30; baseline finish none → 2010-08-05 |
| 52 | Разработать документацию к Системе. Задачи | 2010-04-26 → 2010-09-09 (+136d) | 2010-04-30 → 2010-09-15 (+138d) |  |  | 52d → 0d | none → 51, 41 | baseline start none → 2010-08-06; baseline finish none → 2010-08-12 |
| 53 | Разработать документацию к Системе. Контакты | 2010-04-26 → 2010-09-16 (+143d) | 2010-04-30 → 2010-09-22 (+145d) |  |  | 52d → 0d | none → 52, 42 | baseline start none → 2010-08-13; baseline finish none → 2010-08-19 |
| 54 | Разработать документацию к Системе. Синхронизация и удаленный доступ | 2010-04-26 → 2010-09-01 (+128d) | 2010-04-30 → 2010-09-07 (+130d) |  |  | 52d → 11d | none → 43 | baseline start none → 2010-07-29; baseline finish none → 2010-08-04 |
| 55 | Разработать документацию к Системе. Администрирование и поддержка Системы | 2010-04-26 → 2010-09-16 (+143d) | 2010-04-30 → 2010-09-22 (+145d) |  |  | 52d → 0d | none → 48, 44 | baseline start none → 2010-08-13; baseline finish none → 2010-08-19 |
| 56 | Подписать Акт сдачи-приемки документации к Системе | 2010-04-26 → 2010-09-23 (+150d) | 2010-04-27 → 2010-09-24 (+150d) |  |  | 55d → 0d | none → 50, 51, 52, 53, 54, 55 | baseline start none → 2010-08-20; baseline finish none → 2010-08-23 |
| 57 | Резерв времени на разработку документации к Системе | 2010-04-26 → 2010-09-27 (+154d) | 2010-05-21 → 2010-10-22 (+154d) |  |  | 37d → 0d | none → 56 | baseline start none → 2010-08-24; baseline finish none → 2010-09-20 |
| 58 | Утвердить документацию к Системе на СД | 2010-04-26 → 2010-10-25 (+182d) | 2010-04-30 → 2010-10-29 (+182d) |  |  | 52d → 0d | none → 57 | baseline start none → 2010-09-21; baseline finish none → 2010-09-27 |
| 59 | Ознакомить пользователей с документацией к Системе | 2010-04-26 → 2010-11-01 (+189d) | 2010-04-30 → 2010-11-05 (+189d) |  |  | 52d → 0d | none → 58 | baseline start none → 2010-09-28; baseline finish none → 2010-10-04 |
| 60 | Заказчик принял документацию. Пользователи ознакомлены с документацией | 2010-04-26 → 2010-11-05 (+193d) | 2010-04-26 → 2010-11-05 (+193d) |  |  | 57d → 0d | none → 59 | baseline start none → 2010-10-04; baseline finish none → 2010-10-04 |
| 61 | **Миграция пользователей и настройка клиентских мест** | 2010-04-26 → 2010-08-18 (+114d) | 2010-07-13 → 2010-11-05 (+115d) | 57d → 58d |  |  |  | baseline start none → 2010-07-15; baseline finish none → 2010-10-04 |
| 62 | Подготовить check-list выполнения миграции пользователей | 2010-04-26 → 2010-08-18 (+114d) | 2010-04-30 → 2010-08-24 (+116d) |  |  | 52d → 17d | none → 37 | baseline start none → 2010-07-15; baseline finish none → 2010-07-21 |
| 63 | Проверить check-list. Высказать замечания | 2010-04-26 → 2010-08-25 (+121d) | 2010-04-27 → 2010-08-26 (+121d) |  |  | 55d → 17d | none → 62 | baseline start none → 2010-07-22; baseline finish none → 2010-07-23 |
| 64 | Доработать check-list в соответствии с замечаниями | 2010-04-26 → 2010-08-27 (+123d) | 2010-04-27 → 2010-08-30 (+125d) |  |  | 55d → 17d | none → 63 | baseline start none → 2010-07-26; baseline finish none → 2010-07-27 |
| 65 | Провести миграцию тестовой группы пользователей | 2010-04-26 → 2010-09-09 (+136d) | 2010-04-30 → 2010-09-15 (+138d) |  |  | 52d → 10d | none → 64, 46 | baseline start none → 2010-08-06; baseline finish none → 2010-08-12 |
| 66 | Оценить результаты. Доработать check-list | 2010-04-26 → 2010-09-16 (+143d) | 2010-04-27 → 2010-09-17 (+143d) |  |  | 55d → 10d | none → 65 | baseline start none → 2010-08-13; baseline finish none → 2010-08-16 |
| 67 | Разработать список пользователей к миграции с детализацией до компании | 2010-07-07 → 2010-09-27 (+82d) | 2010-07-13 → 2010-10-01 (+80d) |  |  |  | none → 1 | baseline start none → 2010-08-24; baseline finish none → 2010-08-30 |
| 68 | Согласовать график проведения миграции с пользователями | 2010-04-26 → 2010-10-04 (+161d) | 2010-04-30 → 2010-10-08 (+161d) |  |  | 52d → 0d | none → 67, 66, 87 | baseline start none → 2010-08-31; baseline finish none → 2010-09-06 |
| 69 | Обеспечить миграцию топ-менеджеров, УК | 2010-04-26 → 2010-10-11 (+168d) | 2010-04-30 → 2010-10-15 (+168d) |  |  | 52d → 0d | none → 68 | baseline start none → 2010-09-07; baseline finish none → 2010-09-13 |
| 70 | Подписать акт сдачи-приемки миграции топ-менеджеров и сотрудников УК | 2010-04-26 → 2010-10-15 (+172d) | 2010-04-26 → 2010-10-15 (+172d) |  |  | 57d → 0d | none → 69 | baseline start none → 2010-09-13; baseline finish none → 2010-09-13 |

| ID | Task | Start | Finish | Duration | Complete | Total float | Predecessors | Other |
| --- | --- | --- | --- | --- | --- | --- | --- | --- |
| 71 | Обеспечить миграцию пользователей компании А | 2010-04-26 → 2010-10-18 (+175d) | 2010-04-30 → 2010-10-22 (+175d) |  |  | 52d → 0d | none → 70 | baseline start none → 2010-09-14; baseline finish none → 2010-09-20 |
| 72 | Подписать акт сдачи-приемки миграции А | 2010-04-26 → 2010-10-22 (+179d) | 2010-04-26 → 2010-10-22 (+179d) |  |  | 57d → 0d | none → 71 | baseline start none → 2010-09-20; baseline finish none → 2010-09-20 |
| 73 | Обеспечить миграцию пользователей компании Б | 2010-04-26 → 2010-10-25 (+182d) | 2010-04-30 → 2010-10-29 (+182d) |  |  | 52d → 0d | none → 72 | baseline start none → 2010-09-21; baseline finish none → 2010-09-27 |
| 74 | Подписать акт сдачи-приемки миграции Б | 2010-04-26 → 2010-10-29 (+186d) | 2010-04-26 → 2010-10-29 (+186d) |  |  | 57d → 0d | none → 73 | baseline start none → 2010-09-27; baseline finish none → 2010-09-27 |
| 75 | Обеспечить миграцию пользователей компании В | 2010-04-26 → 2010-11-01 (+189d) | 2010-04-30 → 2010-11-05 (+189d) |  |  | 52d → 0d | none → 74 | baseline start none → 2010-09-28; baseline finish none → 2010-10-04 |
| 76 | Подписать акт сдачи-приемки миграции В | 2010-04-26 → 2010-11-05 (+193d) | 2010-04-26 → 2010-11-05 (+193d) |  |  | 57d → 0d | none → 75 | baseline start none → 2010-10-04; baseline finish none → 2010-10-04 |
| 77 | Обеспечить миграцию пользователей компании Г | 2010-04-26 → 2010-10-11 (+168d) | 2010-04-30 → 2010-10-15 (+168d) |  |  | 52d → 15d | none → 68 | baseline start none → 2010-09-07; baseline finish none → 2010-09-13 |
| 78 | Подписать акт сдачи-приемки миграции Г | 2010-04-26 → 2010-10-15 (+172d) | 2010-04-26 → 2010-10-15 (+172d) |  |  | 57d → 15d | none → 77 | baseline start none → 2010-09-13; baseline finish none → 2010-09-13 |
| 79 | Обеспечить миграцию пользователей филиалов | 2010-04-26 → 2010-10-11 (+168d) | 2010-05-07 → 2010-10-22 (+168d) |  |  | 47d → 10d | none → 68 | baseline start none → 2010-09-07; baseline finish none → 2010-09-20 |
| 80 | Подписать акт сдачи-приемки миграции филиалов | 2010-04-26 → 2010-10-22 (+179d) | 2010-04-26 → 2010-10-22 (+179d) |  |  | 57d → 10d | none → 79 | baseline start none → 2010-09-20; baseline finish none → 2010-09-20 |
| 81 | Миграция пользователей и настройка клиентских мест завершена | 2010-04-26 → 2010-11-05 (+193d) | 2010-04-26 → 2010-11-05 (+193d) |  |  | 57d → 0d | none → 80, 78, 76 | baseline start none → 2010-10-04; baseline finish none → 2010-10-04 |
| 82 | **Оборудование** | 2010-04-26 → 2010-05-10 A (+14d) | 2010-04-30 → 2010-07-29 (+90d) | 5d → 59d | 0% → 43% | 52d → 46d |  | baseline start none → 2010-05-10; baseline finish none → 2010-07-29 |
| 83 | Подать заявку на приобретение оборудования | 2010-04-26 → 2010-05-10 A (+14d) | 2010-04-30 → 2010-05-14 A (+14d) |  | 0% → 100% | 52d → none | none → 1 | baseline start none → 2010-05-10; baseline finish none → 2010-05-14 |
| 84 | Закупить оборудование в соответствии с Заявкой | 2010-04-26 → 2010-05-17 A (+21d) | 2010-04-26 → 2010-05-17 A (+21d) |  | 0% → 100% | 56d → none | none → 83 | baseline start none → 2010-05-17; baseline finish none → 2010-05-17 |
| 85 | Установить оборудование | 2010-04-26 → 2010-07-20 (+85d) | 2010-04-28 → 2010-07-22 (+85d) |  |  | 54d → 46d | none → 84FS+45d | baseline start none → 2010-07-20; baseline finish none → 2010-07-22 |
| 86 | Настроить и проверить работоспособность оборудование | 2010-04-26 → 2010-07-23 (+88d) | 2010-04-30 → 2010-07-29 (+90d) |  |  | 52d → 46d | none → 85 | baseline start none → 2010-07-23; baseline finish none → 2010-07-29 |
| 87 | Оборудование приобретено, настроено и проверено | 2010-04-26 → 2010-07-29 (+94d) | 2010-04-26 → 2010-07-29 (+94d) |  |  | 57d → 46d | none → 86 | baseline start none → 2010-07-29; baseline finish none → 2010-07-29 |
